# Testing.NET

Schedule from MS Project, 2001-01-15 to 2001-06-07, A marks actual dates.
Access360

## Calendars

- Standard: Mon-Fri 08:00-12:00, 13:00-17:00; Sat-Sun off.

## Schedule

| ID | WBS | Task | Duration | Start | Finish | Predecessors | Complete | Remaining | Total slack | Free slack | Constraint |
| --- | --- | --- | --- | --- | --- | --- | --- | --- | --- | --- | --- |
| 1 | 1 | **Verification Testing (Beta Test)** | 75d? | 2001-01-15 A | 2001-04-27 |  | 30% | 52.8d? | 0d |  |  |
| 2 | 1.1 | **Setup and Verification** | 31d? | 2001-01-15 A | 2001-02-26 |  | 65% | 10.78d? | 0d |  |  |
| 3 | 1.1.1 | Installation/Configuration of EnRole | 25d? | 2001-01-15 A | 2001-02-16 |  | 60% | 10d? | 6d |  | start no earlier than 2001-01-15 |
| 4 | 1.1.2 | Installation/Configuration of Iplanet | 25d? | 2001-01-15 A | 2001-02-16 |  | 80% | 5d? | 6d |  | start no earlier than 2001-01-15 |
| 5 | 1.1.3 | Installation/Configuration of Weblogic | 25d? | 2001-01-15 A | 2001-02-16 |  | 80% | 5d? | 6d |  | start no earlier than 2001-01-15 |
| 6 | 1.1.4 | Creation of Load Test Scripts | 11d? | 2001-02-12 A | 2001-02-26 |  | 10% | 9.9d? | 0d |  | start no earlier than 2001-02-12 |
| 7 | 1.2 | **Functional Testing** | 1d? | 2001-02-27 A | 2001-02-27 | 2 | 2% | 0.98d? | 0d |  |  |
| 8 | 1.2.1 | **End User** | 1d? | 2001-02-27 | 2001-02-27 |  |  |  | 0d |  |  |
| 9 | 1.2.1.1 | View Users accesses | 1d? | 2001-02-27 | 2001-02-27 |  |  |  | 0d |  | start no earlier than 2001-02-19 |
| 10 | 1.2.1.2 | Change password on 1 access | 1d? | 2001-02-27 | 2001-02-27 |  |  |  | 0d |  | start no earlier than 2001-02-19 |
| 11 | 1.2.2 | **Dept Manager/HR User** | 1d? | 2001-02-27 A | 2001-02-27 |  | 3% | 0.97d? | 0d |  |  |
| 12 | 1.2.2.1 | Search DB for all users using wildcard | 1d? | 2001-02-27 | 2001-02-27 |  |  |  | 0d |  | start no earlier than 2001-02-20 |
| 13 | 1.2.2.2 | Create a new user | 1d? | 2001-02-27 A | 2001-02-27 |  | 20% | 0.8d? | 0d |  | start no earlier than 2001-02-20 |
| 14 | 1.2.2.3 | Submit 1 access for 1 user | 1d? | 2001-02-27 | 2001-02-27 |  |  |  | 0d |  | start no earlier than 2001-02-20 |
| 15 | 1.2.2.4 | Modify a users personal data | 1d? | 2001-02-27 | 2001-02-27 |  |  |  | 0d |  | start no earlier than 2001-02-21 |
| 16 | 1.2.2.5 | Submit change to 1 user access | 1d? | 2001-02-27 | 2001-02-27 |  |  |  | 0d |  | start no earlier than 2001-02-21 |
| 17 | 1.2.2.6 | Submit 1 access to delete 1 user | 1d? | 2001-02-27 | 2001-02-27 |  |  |  | 0d |  | start no earlier than 2001-02-21 |
| 18 | 1.2.3 | **System Admin User** | 1d? | 2001-02-27 | 2001-02-27 |  |  |  | 0d |  |  |
| 19 | 1.2.3.1 | Search forall systems using wildcard | 1d? | 2001-02-27 | 2001-02-27 |  |  |  | 0d |  | start no earlier than 2001-02-22 |
| 20 | 1.2.3.2 | View all accesses for a system | 1d? | 2001-02-27 | 2001-02-27 |  |  |  | 0d |  | start no earlier than 2001-02-22 |
| 21 | 1.3 | **Performance/HA Testing** | 33d? | 2001-02-28 A | 2001-04-13 | 7 | 11% | 29.51d? | 0d |  |  |
| 22 | 1.3.1 | Load balancing SSL | 11d? | 2001-02-28 A | 2001-03-14 |  | 50% | 5.5d? | 22d |  | start no earlier than 2001-02-09 |
| 23 | 1.3.2 | Failover of web server layer | 1d? | 2001-02-28 | 2001-02-28 |  |  |  | 18d |  | finish no later than 2001-03-26 |
| 24 | 1.3.3 | Failover of Servlet/JVM layer | 1d? | 2001-02-28 | 2001-02-28 |  |  |  | 18d |  | finish no later than 2001-03-26 |
| 25 | 1.3.4 | Failover of Oracle server | 2d? | 2001-02-28 | 2001-03-01 |  |  |  | 19d | 0d | finish no later than 2001-03-28 |
| 26 | 1.3.5 | Failover of Iplanet DS | 2d? | 2001-02-28 | 2001-03-01 |  |  |  | 19d | 0d | finish no later than 2001-03-28 |
| 27 | 1.3.6 | Mean Time Between Failure (MBTF) test | 2d? | 2001-03-02 | 2001-03-05 | 25, 26 |  |  | 20d |  | finish no later than 2001-04-02 |
| 28 | 1.3.7 | Security/Vulnerability test | 3d? | 2001-02-28 | 2001-03-02 |  |  |  | 20d |  | start no later than 2001-03-28 |
| 29 | 1.3.8 | 10k Users in 100 Dept | 5d? | 2001-03-05 | 2001-03-09 | 6 |  |  | 0d |  | start no earlier than 2001-03-05 |
| 30 | 1.3.9 | 25k Users in 1k Dept | 5d? | 2001-03-12 | 2001-03-16 | 29 |  |  | 0d |  | start no earlier than 2001-03-12 |
| 31 | 1.3.10 | 100k Users in 5K Dept | 5d? | 2001-03-19 | 2001-03-23 | 30 |  |  | 0d |  | start no earlier than 2001-03-19 |
| 32 | 1.3.11 | 500k Users in 10k Dept | 5d? | 2001-03-26 | 2001-03-30 | 31 |  |  | 0d |  | start no earlier than 2001-03-26 |
| 33 | 1.3.12 | 1m Users in 25k Dept | 10d? | 2001-04-02 | 2001-04-13 | 32 |  |  | 0d |  | start no earlier than 2001-04-02 |

| ID | WBS | Task | Duration | Start | Finish | Predecessors | Complete | Remaining | Total slack | Free slack | Constraint |
| --- | --- | --- | --- | --- | --- | --- | --- | --- | --- | --- | --- |
| 34 | 1.4 | **MBTF Testing** | 10d? | 2001-04-16 | 2001-04-27 | 21 |  |  | 0d |  |  |
| 35 | 1.4.1 | 72 hour load test | 10d? | 2001-04-16 | 2001-04-27 |  |  |  | 0d |  | start no earlier than 2001-04-16 |
| 36 | 1.5 | **Scenario Testing** | 20d? | 2001-03-05 | 2001-03-30 | 7 |  |  | 10d | 0d |  |
| 37 | 1.5.1 | ASP Scenario | 10d? | 2001-03-05 | 2001-03-16 |  |  |  | 20d |  | start no earlier than 2001-03-05 |
| 38 | 1.5.2 | ASP Internal Scenario | 5d? | 2001-03-19 | 2001-03-23 |  |  |  | 15d |  | start no earlier than 2001-03-19 |
| 39 | 1.5.3 | Enterprise Outsource Scenario | 5d? | 2001-03-26 | 2001-03-30 |  |  |  | 10d |  | start no earlier than 2001-03-26 |
| 40 | 1.6 | **HA Testing** | 10d? | 2001-04-16 A | 2001-04-27 | 7 | 8% | 9.17d? | 0d |  |  |
| 41 | 1.6.1 | Multiple Oracle Backends | 5d? | 2001-04-16 | 2001-04-20 |  |  |  | 5d |  | start no earlier than 2001-04-16 |
| 42 | 1.6.2 | WebLogic JVM Failover | 5d? | 2001-04-23 | 2001-04-27 |  |  |  | 0d |  | start no earlier than 2001-04-23 |
| 43 | 1.6.3 | SSL Load Balance | 5d? | 2001-04-23 A | 2001-04-27 |  | 25% | 3.75d? | 0d |  | start no earlier than 2001-04-23 |
| 44 | 1.7 | **.NET Customer Requirement Testing** | 20d? | 2001-04-02 | 2001-04-27 | 36 |  |  | 0d |  |  |
| 45 | 1.7.1 | HR Feed Testing | 10d? | 2001-04-02 | 2001-04-13 |  |  |  | 10d |  | start no earlier than 2001-04-02 |
| 46 | 1.7.2 | Reporting/Billing tests | 10d? | 2001-04-16 | 2001-04-27 |  |  |  | 0d |  | start no earlier than 2001-04-16 |
| 47 | 2 | **.NET Implementation** | 15d? | 2001-04-30 A | 2001-05-18 | 1 | 3% | 14.61d? | 0d |  |  |
| 48 | 2.1 | **Co Location Discovery** | 5d? | 2001-04-30 A | 2001-05-04 | 21 | 16% | 4.21d? | 2d | 0d |  |
| 49 | 2.1.1 | Identify Co Location Provider and sign contract | 4d? | 2001-04-30 A | 2001-05-03 |  | 25% | 3d? | 2.1d | 0d | finish no earlier than 2001-02-09 |
| 50 | 2.1.2 | Rack Requirements (# AU's to fill, shelves, mounting kits) | 1d? | 2001-05-04 A | 2001-05-04 | 49 | 10% | 0.9d? | 2d |  | start no earlier than 2001-02-12 |
| 51 | 2.1.3 | Power Requirements (# AMPS, APC, Backup power) | 1d? | 2001-04-30 | 2001-04-30 |  |  |  | 6d |  | start no earlier than 2001-02-12 |
| 52 | 2.1.4 | Cabling (APEX/Raritan, Ethernet, Keyboard, Monitor, | 1d? | 2001-04-30 | 2001-04-30 |  |  |  | 6d |  | start no earlier than 2001-02-12 |
| 53 | 2.2 | **Hardware setup** | 4d? | 2001-05-07 | 2001-05-10 | 48 |  |  | 2d | 0d |  |
| 54 | 2.2.1 | Infrastructure setup | 4d? | 2001-05-07 | 2001-05-10 |  |  |  | 2d |  | start no earlier than 2001-02-13 |
| 55 | 2.2.2 | Web servers | 3d? | 2001-05-07 | 2001-05-09 |  |  |  | 3d |  | start no earlier than 2001-02-14 |
| 56 | 2.2.3 | Servlet/JVM machines | 3d? | 2001-05-07 | 2001-05-09 |  |  |  | 3d |  | start no earlier than 2001-02-14 |
| 57 | 2.2.4 | Data Storage | 3d? | 2001-05-07 | 2001-05-09 |  |  |  | 3d |  | start no earlier than 2001-02-14 |

| ID | WBS | Task | Duration | Start | Finish | Predecessors | Total slack | Free slack | Constraint |
| --- | --- | --- | --- | --- | --- | --- | --- | --- | --- |
| 58 | 2.3 | **Software Setup** | 2d? | 2001-05-11 | 2001-05-14 | 53 | 3d | 1d |  |
| 59 | 2.3.1 | Operating Sytems | 2d? | 2001-05-11 | 2001-05-14 |  | 3d |  | start no earlier than 2001-02-14 |
| 60 | 2.3.2 | Weblogic | 2d? | 2001-05-11 | 2001-05-14 |  | 3d |  | start no earlier than 2001-02-15 |
| 61 | 2.3.3 | Oracle | 2d? | 2001-05-11 | 2001-05-14 |  | 3d |  | start no earlier than 2001-02-15 |
| 62 | 2.3.4 | HP Openview | 1d? | 2001-05-11 | 2001-05-11 |  | 4d |  | start no earlier than 2001-02-14 |
| 63 | 2.3.5 | Firewalls | 2d? | 2001-05-11 | 2001-05-14 |  | 3d |  | start no earlier than 2001-02-14 |
| 64 | 2.3.6 | EnRole | 2d? | 2001-05-11 | 2001-05-14 |  | 3d |  | start no earlier than 2001-02-15 |
| 65 | 2.3.7 | Iplanet | 2d? | 2001-05-11 | 2001-05-14 |  | 3d |  | start no earlier than 2001-02-15 |
| 66 | 2.3.8 | Veritas | 2d? | 2001-05-11 | 2001-05-14 |  | 3d |  | start no earlier than 2001-02-14 |
| 67 | 2.4 | **Network Setup** | 3d? | 2001-05-11 | 2001-05-15 | 53 | 2d | 0d |  |
| 68 | 2.4.1 | Firewalls | 3d? | 2001-05-11 | 2001-05-15 |  | 2d |  | start no earlier than 2001-02-14 |
| 69 | 2.4.2 | Switches | 2d? | 2001-05-11 | 2001-05-14 |  | 3d |  | start no earlier than 2001-02-13 |
| 70 | 2.5 | **Testing** | 3d? | 2001-05-16 | 2001-05-18 | 53, 58, 67 | 0d |  |  |
| 71 | 2.5.1 | Restoration from hard backup test | 1d? | 2001-05-16 | 2001-05-16 |  | 2d |  | start no earlier than 2001-02-23 |
| 72 | 2.5.2 | Data Live verification | 1d? | 2001-05-18 | 2001-05-18 |  | 0d |  | finish no earlier than 2001-05-18 |
| 73 | 3 | **Verisign deployment and acceptance** | 14d? | 2001-05-21 | 2001-06-07 | 47 | 0d |  |  |
| 74 | 3.1 | **Test Phase** | 8d? | 2001-05-21 | 2001-05-30 |  | 0d |  |  |
| 75 | 3.1.1 | Submission of .NET code deployment to Verisign | 1d | 2001-05-21 | 2001-05-21 |  | 0d |  |  |
| 76 | 3.1.2 | Acceptance by Verisign of .NET code deployment | 2d | 2001-05-22 | 2001-05-23 | 75 | 0d |  |  |
| 77 | 3.1.3 | Production Services Deployment | 1d? | 2001-05-24 | 2001-05-24 | 76 | 0d |  |  |
| 78 | 3.1.4 | Perform test | 1d? | 2001-05-25 | 2001-05-25 | 77 | 0d |  |  |
| 79 | 3.1.5 | Evaluate | 1d? | 2001-05-28 | 2001-05-28 | 78 | 0d |  |  |
| 80 | 3.1.6 | Correct problems | 2d | 2001-05-29 | 2001-05-30 | 79 | 0d |  |  |
| 81 | 3.2 | **Production Phase** | 6d? | 2001-05-31 | 2001-06-07 | 74 | 0d |  |  |
| 82 | 3.2.1 | Submission of .NET code deployment to Verisign | 1d | 2001-05-31 | 2001-05-31 |  | 0d |  |  |
| 83 | 3.2.2 | Acceptance by Verisign of .NET code deployment | 2d | 2001-06-01 | 2001-06-04 | 82 | 0d |  |  |
| 84 | 3.2.3 | Production Services Deployment | 1d? | 2001-06-05 | 2001-06-05 | 83 | 0d |  |  |
| 85 | 3.2.4 | Perform test | 0.5d | 2001-06-06 | 2001-06-06 | 84 | 0d |  |  |
| 86 | 3.2.5 | Evaluate | 0.5d? | 2001-06-06 | 2001-06-06 | 85 | 0d |  |  |
| 87 | 3.2.6 | Deploy for Production | 1d? | 2001-06-07 | 2001-06-07 | 86 | 0d |  |  |
